# COSTA_RICA_SIPN_Project_Plan

Schedule from MS Project, 2026-10-30 to 2028-01-07.

## Calendars

- Standard: Mon-Fri 08:00-12:00, 13:00-17:00; Sat-Sun off. Exceptions (off unless hours are given): 2027-11-28 08:00-12:00, 13:00-17:00.

## Resources

| Resource |
| --- |
| Gerente de Proyecto |
| Gerente de Proyecto + Analistas |
| Gerente de Proyectos + Ingenieros de Soporte |
| Staff de Soporte |
| Analistas |
| Desarrolladores (Analistas) |
| Desarrolladores (Analistas) + Analistas |
| Analistas + Desarrolladores (Analistas) |
| Gerente de Proyecto + Desarrolladores (Analistas) |
| Gerente de Proyecto + Legal |

## Schedule

| ID | WBS | Task | Type | Duration | Start | Finish | Predecessors | Total slack | Free slack | Constraint | Resources | Work |
| --- | --- | --- | --- | --- | --- | --- | --- | --- | --- | --- | --- | --- |
| 1 | 1 | **Firma del Contrato e Inicio del Proyecto** |  | 11d | 2026-10-30 | 2026-11-13 |  | 5d |  |  |  | 56h |
| 2 | 1.1 | Constitución de la Fianza de Cumplimiento y Confirmación Bancaria |  | 1d | 2026-10-30 | 2026-10-30 |  | 5d | 0d | finish no earlier than 2026-10-30 | Gerente de Proyecto | 8h |
| 3 | 1.2 | Presentar los Acuerdos de Confidencialidad al Consejo de SUTEL para su Aprobación |  | 5d | 2026-11-02 | 2026-11-06 | 2 | 5d | 0d |  |  |  |
| 4 | 1.3 | Acuerdos de Confidencialidad firmados con todos los miembros del CTPN-M |  | 3d | 2026-11-09 | 2026-11-11 | 2, 3 | 5d | 0d |  | Gerente de Proyecto | 24h |
| 5 | 1.4 | Designación de los puntos de contacto del proyecto |  | 2d | 2026-11-12 | 2026-11-13 | 4 | 301d |  |  | Gerente de Proyecto | 16h |
| 6 | 1.5 | Inicio Interno del Proyecto - Equipo Mediafon |  | 1d | 2026-11-12 | 2026-11-12 | 4 | 302d |  |  | Gerente de Proyecto | 8h |
| 7 | 1.6 | Punto de Control 1 — Cierre Contractual | milestone | 0d | 2026-11-11 | 2026-11-11 | 4 | 5d | 0d |  |  |  |
| 8 | 2 | **Pre-Implementación y Configuración de la Gobernanza** |  | 58d | 2026-11-12 | 2027-02-01 |  | 5d |  |  |  | 360h |
| 9 | 2.1 | Mapeo de Interesados y Protocolo de Contacto (SUTEL, CTPN-F, Operadores) |  | 5d | 2026-11-12 | 2026-11-18 | 7 | 5d | 0d |  | Gerente de Proyecto + Analistas | 40h |
| 10 | 2.2 | Configuración de la Estructura de Gobernanza — Comité Directivo, Grupos de Trabajo y Cadencia de Comunicación |  | 3d | 2026-11-12 | 2026-11-16 | 7 | 300d |  |  | Gerente de Proyecto | 24h |
| 11 | 2.3 | Levantamiento de Requerimientos e Información del Proveedor Actual (Inetum) |  | 5d | 2026-11-12 | 2026-11-18 | 7 | 5d | 0d |  | Gerente de Proyecto + Analistas | 40h |
| 12 | 2.4 | Preparativos Previos al Desarrollo de NUMLEX™ (NIPs e Interfaces) |  | 21d | 2027-01-04 | 2027-02-01 | 7 | 28d | 0d | finish no earlier than 2027-02-01 | Gerente de Proyecto + Analistas | 168h |
| 13 | 2.5 | Inicio del Proceso de Adquisiciones |  | 4d | 2026-11-19 | 2026-11-24 | 9, 11 | 5d | 0d |  | Gerente de Proyectos + Ingenieros de Soporte | 32h |
| 14 | 2.6 | Emisión de órdenes de Compra de Hardware |  | 4d | 2026-11-25 | 2026-11-30 | 13 | 5d | 0d |  | Staff de Soporte | 32h |
| 15 | 2.7 | Finalización de la Documentación y Aprobaciones |  | 3d | 2026-12-01 | 2026-12-03 | 14 | 5d | 0d |  | Gerente de Proyecto + Analistas | 24h |
| 16 | 2.8 | Preimplementación Completada | milestone | 0d | 2026-12-03 | 2026-12-03 | 15 | 5d | 0d |  | Gerente de Proyecto |  |
| 17 | 3 | **Especificaciones de la Solución y Talleres (Workshop)** |  | 37d | 2026-12-03 | 2027-01-25 |  | 5d |  |  |  | 400h |
| 18 | 3.1 | Reunión de Inicio del Proyecto (Kick-off meeting SUTEL y CTPN-F) |  | 1d | 2026-12-04 | 2026-12-04 | 16 | 59d | 0d |  | Gerente de Proyecto + Analistas | 8h |
| 19 | 3.2 | Entrega del Manual de Interfaces y Procesos |  | 16d | 2027-01-04 | 2027-01-25 | 7 | 38d | 0d | finish no earlier than 2027-01-25 | Gerente de Proyecto + Desarrolladores (Analistas) | 128h |
| 20 | 3.3 | Workshop 1 - Arquitectura del Sistema y Procesos de Portabilidad |  | 3d | 2026-12-07 | 2026-12-09 | 18 | 271d | 0d |  | Gerente de Proyecto + Analistas | 24h |
| 21 | 3.4 | Workshop 2 - Requerimientos de Integración e Interfaces |  | 2d | 2026-12-10 | 2026-12-11 | 20 | 271d | 0d |  | Gerente de Proyecto + Analistas | 16h |
| 22 | 3.5 | Especificación y Confirmación del Servicio de Consulta de Operador |  | 5d | 2026-12-14 | 2026-12-18 | 21 | 276d |  |  | Desarrolladores (Analistas) | 40h |
| 23 | 3.6 | Confirmación de la Especificación de la Interfaz Carrier Lookup y RP-SUTEL |  | 3d | 2026-12-14 | 2026-12-16 | 21 | 278d |  |  | Desarrolladores (Analistas) | 24h |
| 24 | 3.7 | Revisión Analítica y Evaluación de Brechas |  | 10d | 2026-12-14 | 2026-12-25 | 21 | 271d |  |  | Analistas | 80h |
| 25 | 3.8 | Preparación de la Documentación y Finalización de Especificaciones |  | 10d | 2026-12-14 | 2026-12-25 | 21 | 271d |  |  | Analistas | 80h |
| 26 | 3.9 | Selección y Configuración de Plataforma Independiente de Monitoreo de Terceros |  | 15d | 2026-12-07 | 2026-12-25 | 18 | 59d | 21d |  |  |  |
| 27 | 3.10 | Especificaciones y Plan de Implementación Aprobados por SUTEL y CTPN-F | milestone | 0d | 2026-12-03 | 2026-12-03 | 16 | 5d | 0d |  | Gerente de Proyecto |  |
| 28 | 3.11 | Punto de Control 2 - Línea Base Técnica Congelada | milestone | 0d | 2027-01-25 | 2027-01-25 | 19, 26 | 38d | 10d | start no earlier than 2027-01-25 |  |  |

Notes:
- 28: Gate 2 Technical Baseline Frozen/ From here, any change is a Change Request.

| ID | WBS | Task | Type | Duration | Start | Finish | Predecessors | Total slack | Free slack | Resources | Work |
| --- | --- | --- | --- | --- | --- | --- | --- | --- | --- | --- | --- |
| 29 | 4 | **Preparativos Internos de los Operadores** |  | 47d | 2026-12-04 | 2027-02-08 |  | 28d |  |  | 160h |
| 30 | 4.1 | Preparativos Internos de los Operadores para Conectarse a NUMLEX™ |  | 20d | 2026-12-04 | 2026-12-31 | 27 | 55d | 27d | Analistas | 160h |
| 31 | 4.2 | Preparación del Desarrollo de NUMLEX™ para la Integración de Operadores |  | 5d | 2027-02-02 | 2027-02-08 | 12 | 28d | 0d |  |  |
| 32 | 4.3 | Preparativos Internos de los Operadores Completados | milestone | 0d | 2027-02-08 | 2027-02-08 | 30, 31, 28 | 28d | 5d | Gerente de Proyecto |  |
| 33 | 5 | **Implementación de la Infraestructura de NUMLEX™** |  | 95d | 2026-12-01 | 2027-04-12 |  | 18d |  |  | 984h |
| 34 | 5.1 | Compra y Entrega de Hardware |  | 40d | 2026-12-01 | 2027-01-25 | 14 | 18d | 0d | Staff de Soporte | 320h |
| 35 | 5.2 | Preparación del Sitio Principal y del Sitio de Recuperación para la Instalación |  | 10d | 2027-01-26 | 2027-02-08 | 34 | 18d | 0d | Staff de Soporte | 80h |
| 36 | 5.3 | Configuración y Pruebas del Enlace de Replicación del Sitio (DR) |  | 5d | 2027-02-09 | 2027-02-15 | 35 | 232d | 0d | Desarrolladores (Analistas) | 40h |
| 37 | 5.4 | Configuración y Pruebas de Conmutación DNS (Sitio Principal hacia DR) |  | 3d | 2027-02-16 | 2027-02-18 | 36 | 232d |  | Desarrolladores (Analistas) | 24h |
| 38 | 5.5 | Instalación del Hardware de Servidores |  | 5d | 2027-02-09 | 2027-02-15 | 35, 34 | 18d | 0d | Staff de Soporte | 40h |
| 39 | 5.6 | Instalación de Equipos de Comunicaciones |  | 5d | 2027-02-09 | 2027-02-15 | 35 | 23d | 0d | Staff de Soporte | 40h |
| 40 | 5.7 | Instalación y Configuración de Sistemas Operativos |  | 10d | 2027-02-16 | 2027-03-01 | 38 | 18d | 0d | Desarrolladores (Analistas) | 80h |
| 41 | 5.8 | Pruebas de Software y Hardware |  | 5d | 2027-03-02 | 2027-03-08 | 40 | 18d | 0d | Analistas | 40h |
| 42 | 5.9 | Configuración de Conexiones VPN Internas |  | 10d | 2027-02-16 | 2027-03-01 | 39, 32 | 23d | 0d | Desarrolladores (Analistas) | 80h |
| 43 | 5.10 | Instalación de Líneas de Comunicación de los Operadores (VPN, Líneas Dedicadas) |  | 20d | 2027-03-02 | 2027-03-29 | 42 | 98d | 0d | Desarrolladores (Analistas) | 160h |
| 44 | 5.11 | Pruebas de Comunicación con los Operadores |  | 10d | 2027-03-30 | 2027-04-12 | 43, 39, 30 | 98d | 0d | Desarrolladores (Analistas) | 80h |
| 45 | 5.12 | Infraestructura Lista | milestone | 0d | 2027-03-08 | 2027-03-08 | 41, 42 | 18d | 0d | Gerente de Proyecto |  |
| 46 | 6 | **Instalación de los Sistemas de Mesa de Ayuda y Monitoreo** |  | 25d | 2027-03-09 | 2027-04-12 |  | 108d |  |  | 280h |
| 47 | 6.1 | Instalación del sistema de soporte |  | 15d | 2027-03-09 | 2027-03-29 | 45 | 195d | 0d | Desarrolladores (Analistas) | 120h |
| 48 | 6.2 | Configuración del sistema de monitoreo de hardware y software |  | 15d | 2027-03-09 | 2027-03-29 | 45 | 108d | 10d | Desarrolladores (Analistas) | 120h |
| 49 | 6.3 | Configuración del seguimiento y generación de reportes de SLA |  | 5d | 2027-03-30 | 2027-04-05 | 47 | 195d | 0d | Desarrolladores (Analistas) | 40h |
| 50 | 6.4 | Los siete SLA instrumentados y con monitoreo activo |  | 5d | 2027-04-06 | 2027-04-12 | 49 | 195d |  |  |  |
| 51 | 6.5 | Punto de Control 3 - Infraestructura y Conectividad Validadas | milestone | 0d | 2027-04-12 | 2027-04-12 | 48, 44 | 98d | 0d | Gerente de Proyecto |  |
| 52 | 7 | **Configuración de NUMLEX™ y Aceptación de Fábrica** |  | 85d | 2026-12-04 | 2027-04-01 |  | 5d |  |  | 400h |
| 53 | 7.1 | Configuración de la plataforma NUMLEX™ para el entorno regulatorio de Costa Rica |  | 20d | 2026-12-04 | 2026-12-31 | 27 | 5d | 0d | Desarrolladores (Analistas) | 160h |
| 54 | 7.2 | Modo de Operador Offline — Diseño, Configuración y Pruebas |  | 10d | 2027-01-01 | 2027-01-14 | 53 | 5d | 0d |  |  |
| 55 | 7.3 | Configuración de la capa de enrutamiento de Esquema Dual |  | 10d | 2027-01-15 | 2027-01-28 | 53, 54 | 5d | 0d | Desarrolladores (Analistas) | 80h |
| 56 | 7.4 | Desarrollo e integración de RP-SUTEL y pruebas unitarias |  | 15d | 2027-01-29 | 2027-02-18 | 55 | 5d | 0d |  |  |
| 57 | 7.5 | Desarrollo y pruebas unitarias del servicio Carrier Lookup |  | 10d | 2027-02-19 | 2027-03-04 | 56 | 5d | 0d |  |  |
| 58 | 7.6 | Revisión de pruebas |  | 5d | 2027-03-05 | 2027-03-11 | 57 | 5d | 0d | Analistas | 40h |
| 59 | 7.7 | Troubleshooting y Gestión de Cambios |  | 5d | 2027-03-12 | 2027-03-18 | 58 | 5d | 0d | Desarrolladores (Analistas) | 40h |
| 60 | 7.8 | Pruebas de Aceptación en Fábrica (FAT) |  | 5d | 2027-03-19 | 2027-03-25 | 59 | 5d | 0d | Desarrolladores (Analistas) + Analistas | 40h |
| 61 | 7.9 | Sistemas productivos listos para instalación | milestone | 0d | 2027-03-25 | 2027-03-25 | 60 | 5d | 0d | Gerente de Proyecto |  |
| 62 | 7.10 | Instalación de Sistemas en Producción |  | 5d | 2027-03-26 | 2027-04-01 | 61, 45 | 5d | 0d | Desarrolladores (Analistas) | 40h |
| 63 | 7.11 | Sistema de producción NUMLEX™ instalado | milestone | 0d | 2027-04-01 | 2027-04-01 | 62 | 26d | 0d | Gerente de Proyecto |  |

| ID | WBS | Task | Type | Duration | Start | Finish | Predecessors | Total slack | Free slack | Constraint | Resources | Work |
| --- | --- | --- | --- | --- | --- | --- | --- | --- | --- | --- | --- | --- |
| 64 | 8 | **Componentes Específicos SIPN** |  | 43d | 2027-03-09 | 2027-05-06 |  | 177d |  |  |  | 640h |
| 65 | 8.1 | **Generación NIP y Servicios IVR** |  | 30d | 2027-03-09 | 2027-04-19 |  | 190d |  |  |  | 240h |
| 66 | 8.1.1 | Diseño y configuración del servicio de generación de NIP |  | 20d | 2027-03-09 | 2027-04-05 | 27, 45 | 190d | 0d |  | Desarrolladores (Analistas) | 160h |
| 67 | 8.1.2 | Implementación del Servicio IVR |  | 10d | 2027-04-06 | 2027-04-19 | 66 | 190d |  |  | Desarrolladores (Analistas) | 80h |
| 68 | 8.2 | **Portal público de Portabilidad** |  | 25d | 2027-04-02 | 2027-05-06 |  | 177d |  |  |  | 200h |
| 69 | 8.2.1 | Desarrollo del Portal Público (seguimiento del Estado de Portabilidad) |  | 25d | 2027-04-02 | 2027-05-06 | 63 | 177d | 0d |  | Desarrolladores (Analistas) | 200h |
| 70 | 8.2.2 | Portal Público listo | milestone | 0d | 2027-05-06 | 2027-05-06 | 69 | 177d |  |  | Gerente de Proyecto |  |
| 71 | 8.3 | **Repositorio de documentos CTPN-M (CTPN-F)** |  | 15d | 2027-04-02 | 2027-04-22 |  | 187d |  |  |  | 120h |
| 72 | 8.3.1 | Configuración del repositorio (manuales, arquitectura, diagramas de comunicaciones) |  | 15d | 2027-04-02 | 2027-04-22 | 63 | 187d |  |  | Desarrolladores (Analistas) | 120h |
| 73 | 8.4 | **Archivo diario de números portados y configuración de SFTP** |  | 10d | 2027-04-02 | 2027-04-15 |  | 192d |  |  |  | 80h |
| 74 | 8.4.1 | Actualización de Base de Datos con frecuencia configurable y configuración de Ventana de Cambios |  | 10d | 2027-04-02 | 2027-04-15 | 63 | 192d |  |  | Desarrolladores (Analistas) | 80h |
| 75 | 9 | **Capacitación** |  | 99d | 2027-04-02 | 2027-08-18 |  | 26d |  |  |  | 488h |
| 76 | 9.1 | Preparación de materiales de Capacitación. |  | 57d | 2027-04-02 | 2027-06-21 | 63 | 26d | 0d | finish no earlier than 2027-06-04 | Analistas | 456h |
| 77 | 9.2 | Capacitación - Operadores: Operación diaria y cumplimiento de SLA |  | 2d | 2027-08-13 | 2027-08-16 | 76FS+38d | 26d | 0d |  | Gerente de Proyecto + Analistas | 16h |
| 78 | 9.3 | Capacitación - SUTEL: Monitoreo, auditoría y ejecución de procesos |  | 1d | 2027-08-17 | 2027-08-17 | 77 | 26d | 0d |  | Gerente de Proyecto + Analistas | 8h |
| 79 | 9.4 | Capacitación - Administradores CTPN-F: Gestión del proceso de portabilidad |  | 1d | 2027-08-18 | 2027-08-18 | 78 | 26d | 0d |  | Gerente de Proyecto + Analistas | 8h |
| 80 | 9.5 | Capacitación completada y cierre de aceptación | milestone | 0d | 2027-08-18 | 2027-08-18 | 79 | 26d | 9d |  | Gerente de Proyecto |  |
| 81 | 10 | **Preparación para la migración** |  | 185d | 2027-02-01 | 2027-10-15 |  | 34d |  |  |  | 928h |
| 82 | 10.1 | Solicitud de estructura de datos ERPN del operador incumbente, esquemas, descripciones de campos y datos de ejemplo |  | 5d | 2027-02-01 | 2027-02-05 | 27FS+41d | 34d | 0d |  | Analistas | 40h |
| 83 | 10.2 | Datos parciales de migración recibidos del ERPN actual | milestone | 0d | 2027-02-05 | 2027-02-05 | 82 | 34d | 0d |  | Gerente de Proyecto |  |
| 84 | 10.3 | Levantamiento de la estructura de base de datos del ERPN del operador incumbente y análisis del formato de datos (primer test de migración) (con los datos proporcionados por el ERPN actual) |  | 10d | 2027-02-08 | 2027-02-19 | 83 | 34d | 0d |  | Analistas | 80h |
| 85 | 10.4 | Preparación del entorno de pruebas de migración |  | 10d | 2027-02-22 | 2027-03-05 | 82, 84 | 201d | 0d |  | Desarrolladores (Analistas) | 80h |
| 86 | 10.5 | Preparación de herramientas de migración y scripts de conversión de datos |  | 5d | 2027-03-08 | 2027-03-12 | 85 | 201d | 0d |  | Desarrolladores (Analistas) | 40h |
| 87 | 10.6 | Extracción parcial de datos del incumbente — preparación de datos de prueba |  | 5d | 2027-03-15 | 2027-03-19 | 86 | 201d | 0d |  | Desarrolladores (Analistas) | 40h |
| 88 | 10.7 | Migración de prueba al entorno de pruebas de NUMLEX™ — validación de integridad y corrección de incidencias |  | 10d | 2027-03-22 | 2027-04-02 | 87 | 201d |  |  | Analistas | 80h |
| 89 | 10.8 | Definición y validación del alcance de migración de datos históricos (periodo completo requerido por CTPN-M y SUTEL) |  | 5d | 2027-04-02 | 2027-04-08 | 84, 62 | 5d | 0d |  | Analistas + Desarrolladores (Analistas) | 40h |
| 90 | 10.9 | Plan detallado de migración enviado a CTPN-M para su aprobación |  | 1d | 2027-04-09 | 2027-04-09 | 89 | 5d | 0d |  | Desarrolladores (Analistas) | 8h |
| 91 | 10.10 | Periodo de revisión de CTPN-M |  | 20d | 2027-04-12 | 2027-05-07 | 90 | 5d | 0d |  | Desarrolladores (Analistas) | 160h |
| 92 | 10.11 | Mediafon atiende los comentarios y revisiones de CTPN-M |  | 20d | 2027-05-10 | 2027-06-04 | 91 | 5d | 0d |  | Desarrolladores (Analistas) | 160h |
| 93 | 10.12 | Plan de migración aprobado por CTPN-M | milestone | 0d | 2027-08-11 | 2027-08-11 | 92FS+48d | 5d | 0d |  | Desarrolladores (Analistas) |  |
| 94 | 10.13 | Levantamiento de la infraestructura existente del operador |  | 10d | 2027-09-09 | 2027-09-22 | 93FS+20d | 5d | 0d |  | Desarrolladores (Analistas) | 80h |
| 95 | 10.14 | Herramientas y entorno de migración listos | milestone | 0d | 2027-09-22 | 2027-09-22 | 94 | 5d | 0d |  | Desarrolladores (Analistas) |  |
| 96 | 10.15 | Recepción actualizada del Snapshot de datos del ERPN incumbente para Ronda 1 |  | 2d | 2027-09-23 | 2027-09-24 | 95 | 5d | 0d |  |  |  |
| 97 | 10.16 | Ronda 1 Ensayo de migración — migración de datos y verificación de integridad |  | 5d | 2027-09-27 | 2027-10-01 | 96 | 5d | 0d |  | Desarrolladores (Analistas) | 40h |
| 98 | 10.17 | Migración Ronda 1 — Validación de Integridad y Registro de Incidencias |  | 3d | 2027-10-04 | 2027-10-06 | 97 | 5d | 0d |  | Analistas | 24h |
| 99 | 10.18 | Recepción actualizada del snapshot de datos del ERPN incumbente para Ronda 2 |  | 2d | 2027-10-07 | 2027-10-08 | 98 | 5d | 0d |  | Analistas | 16h |
| 100 | 10.19 | Ronda 2 Ensayo de migración — validación de correcciones y medición de duración |  | 3d | 2027-10-11 | 2027-10-13 | 99 | 5d | 0d |  | Desarrolladores (Analistas) | 24h |
| 101 | 10.20 | Migración Ronda 2 — Validación de Integridad completada |  | 2d | 2027-10-14 | 2027-10-15 | 100 | 5d | 0d |  | Analistas | 16h |
| 102 | 10.21 | Finalización de pruebas de ajustes internos de NUMLEX™ y del Operador | milestone | 0d | 2027-10-15 | 2027-10-15 | 101 | 61d | 0d | start no earlier than 2027-08-31 | Gerente de Proyecto |  |
| 103 | 10.22 | Pruebas de migración finalizadas - Herramientas y entorno listos | milestone | 0d | 2027-10-15 | 2027-10-15 | 101 | 5d | 0d |  | Gerente de Proyecto |  |

| ID | WBS | Task | Type | Duration | Start | Finish | Predecessors | Total slack | Free slack | Constraint | Resources | Work |
| --- | --- | --- | --- | --- | --- | --- | --- | --- | --- | --- | --- | --- |
| 104 | 11 | **Pruebas de Aceptación del Sistema** |  | 141d | 2027-04-13 | 2027-10-26 |  | 54d |  |  |  | 800h |
| 105 | 11.1 | Pruebas de Aceptación en Sitio |  | 10d | 2027-04-13 | 2027-04-26 | 63, 51 | 98d | 0d |  | Analistas | 80h |
| 106 | 11.2 | Fase de Pruebas de Desarrollo |  | 10d | 2027-04-27 | 2027-05-10 | 105 | 98d | 0d |  | Desarrolladores (Analistas) | 80h |
| 107 | 11.3 | Pruebas de Redundancia del Sistema |  | 10d | 2027-05-11 | 2027-05-24 | 106 | 135d | 0d |  | Desarrolladores (Analistas) | 80h |
| 108 | 11.4 | Pruebas de Recuperación ante Desastres |  | 10d | 2027-05-25 | 2027-06-07 | 107 | 135d | 0d |  | Desarrolladores (Analistas) | 80h |
| 109 | 11.5 | Pruebas de Estrés, Regresión y Soporte/Mantenimiento |  | 10d | 2027-06-08 | 2027-06-21 | 108 | 135d | 0d |  | Desarrolladores (Analistas) | 80h |
| 110 | 11.6 | Pruebas de Seguridad |  | 10d | 2027-06-22 | 2027-07-05 | 109 | 135d | 41d |  | Desarrolladores (Analistas) | 80h |
| 111 | 11.7 | Inicio de la Fase de Pruebas Integrales | milestone | 0d | 2027-09-01 | 2027-09-01 | 110 | 94d |  | start no earlier than 2027-09-01 |  |  |
| 112 | 11.8 | Pruebas de Integración |  | 5d | 2027-09-01 | 2027-09-07 | 80, 51, 106 | 17d | 0d | start no earlier than 2027-09-01 | Analistas | 40h |
| 113 | 11.9 | Pruebas de integración de comunicaciones SIPN |  | 5d | 2027-09-08 | 2027-09-14 | 51, 112 | 17d | 0d | start no earlier than 2027-08-03 | Desarrolladores (Analistas) + Analistas | 40h |
| 114 | 11.10 | Aceptación de pruebas de Integración |  | 5d | 2027-09-15 | 2027-09-21 | 113 | 17d | 0d |  | Analistas | 40h |
| 115 | 11.11 | Pruebas de Interoperabilidad |  | 10d | 2027-09-22 | 2027-10-05 | 114 | 17d | 0d |  | Analistas + Desarrolladores (Analistas) | 80h |
| 116 | 11.12 | Pruebas paralelas de Esquema Dual |  | 5d | 2027-10-06 | 2027-10-12 | 115 | 17d | 0d |  | Desarrolladores (Analistas) | 40h |
| 117 | 11.13 | Informe de resultados de Pruebas y Documentación del Punto de Control 4 |  | 10d | 2027-10-13 | 2027-10-26 | 116 | 17d | 0d |  | Gerente de Proyecto + Analistas | 80h |
| 118 | 11.14 | Punto de Control 4 — Decisión de Go/No-Go de Preparación Operativa | milestone | 0d | 2027-10-26 | 2027-10-26 | 117 | 17d | 12d |  | Gerente de Proyecto |  |
| 119 | 12 | **Migración final y Lanzamiento Comercial** |  | 59d | 2027-10-20 | 2028-01-07 |  | 0d |  |  |  | 448h |
| 120 | 12.1 | Recepción del snapshot de datos del ERPN incumbente para la Ronda 3 de migración |  | 2d | 2027-10-20 | 2027-10-21 | 103FS+2d | 5d | 0d |  | Analistas | 16h |
| 121 | 12.2 | Verificación de integridad de datos y pruebas previas a la migración |  | 2d | 2027-10-22 | 2027-10-25 | 120 | 5d | 0d |  | Analistas | 16h |
| 122 | 12.3 | Simulación de migración Ronda 3 — Snapshot pre-Producción |  | 8d | 2027-10-26 | 2027-11-04 | 121 | 5d | 0d |  | Desarrolladores (Analistas) | 64h |
| 123 | 12.4 | Migración Ronda 3 — Validación de Integridad y Revisión de CTPN-M |  | 2d | 2027-11-05 | 2027-11-08 | 122 | 5d | 0d |  | Analistas | 16h |
| 124 | 12.5 | Pruebas de Aceptación de Usuario post-Migración |  | 3d | 2027-11-09 | 2027-11-11 | 123 | 5d | 0d |  | Analistas | 24h |
| 125 | 12.6 | Preparación del MoP de Cutover, plan de Rollback, War Room y Métricas |  | 3d | 2027-11-05 | 2027-11-09 | 122 | 44d |  |  |  |  |
| 126 | 12.7 | Aceptación parcial de la migración por CTPN-M | milestone | 0d | 2027-11-12 | 2027-11-12 | 124, 118 | 5d | 0d | start no earlier than 2027-11-12 | Gerente de Proyecto + Analistas |  |
| 127 | 12.8 | Validación final del Entorno de Producción |  | 2d | 2027-11-12 | 2027-11-15 | 124, 118, 126 | 5d | 0d |  | Gerente de Proyecto | 16h |
| 128 | 12.9 | Carga final de la Configuración del Sistema Comercial |  | 4d | 2027-11-16 | 2027-11-19 | 127 | 5d | 0d |  | Desarrolladores (Analistas) | 32h |
| 129 | 12.10 | Todas las conexiones de Operadores verificadas contra Producción NUMLEX™ — confirmación Go/No-Go |  | 1d | 2027-11-22 | 2027-11-22 | 128 | 5d |  |  | Desarrolladores (Analistas) | 8h |
| 130 | 12.11 | Decisión final de Go/No-Go — Inicio Comercial Confirmado | milestone | 0d | 2027-11-29 | 2027-11-29 | 129 | 0d |  | start no earlier than 2027-11-29 | Gerente de Proyecto |  |
| 131 | 12.12 | Cierre regulatorio final (SUTEL) confirmado |  | 1d | 2027-11-29 | 2027-11-29 | 130 | 0d |  |  | Gerente de Proyecto | 8h |
| 132 | 12.13 | NUMLEX™ SIPN Costa Rica entra en Operación en Vivo |  | 1d | 2027-11-30 | 2027-11-30 | 131 | 0d |  |  | Analistas + Desarrolladores (Analistas); Gerente de Proyecto; Staff de Soporte | 24h |
| 133 | 12.14 | Inicio oficial de la Operación Comercial - NUMLEX™ SIPN Costa Rica | milestone | 0d | 2027-11-30 | 2027-11-30 | 132 | 0d |  | finish no earlier than 2027-11-30 | Gerente de Proyecto |  |
| 134 | 12.15 | Estabilización Post Go-Live y ajuste fino Operativo |  | 23d | 2027-12-01 | 2027-12-31 | 133 | 0d |  |  | Gerente de Proyecto | 184h |
| 135 | 12.16 | Cierre del Proyecto y entrega al Equipo de Operaciones |  | 5d | 2028-01-03 | 2028-01-07 | 134 | 0d |  |  | Gerente de Proyecto | 40h |
